# ERP_Implementation_2

Schedule from MS Project, 2006-03-13 to 2007-02-14, costs in $.

## Calendars

- Standard: Mon-Fri 08:00-12:00, 13:00-17:00; Sat-Sun off.

## Resources

| Resource | Rate |
| --- | --- |
| Business Analyst | 50 |
| Project Manager | 75 |
| Designer | 40 |
| Developer | 30 |
| Tester | 30 |
| Admin Asst | 12 |
| CMGT Project Team | 12 |
| Trainer | 30 |

## Schedule

| ID | WBS | Task | Duration | Start | Finish | Predecessors | Total slack | Constraint | Resources | Work | Cost |
| --- | --- | --- | --- | --- | --- | --- | --- | --- | --- | --- | --- |
| 1 | 1 | **Project Plan for New Benefits Election System** | 243d? | 2006-03-13 | 2007-02-14 |  | 0d |  |  | 976h | 37,864 |
| 2 | 1.1 | **Define Problem** | 20d | 2006-08-29 | 2006-09-25 |  | 0d |  |  | 160h | 4,944 |
| 3 | 1.1.1 | Understand Organizational Context of Huffman Trucking HR Dept | 3d | 2006-08-29 | 2006-08-31 |  | 0d | start no earlier than 2006-08-29 | CMGT Project Team | 24h | 288 |
| 4 | 1.1.2 | Understand the history of the problem with Benefits tracking System | 2d | 2006-09-01 | 2006-09-04 | 3 | 0d | start no earlier than 2006-03-15 | CMGT Project Team | 16h | 192 |
| 5 | 1.1.3 | Identify the team to work on the Implementation project | 3d | 2006-09-05 | 2006-09-07 | 4 | 0d | start no earlier than 2006-03-22 | CMGT Project Team | 24h | 288 |
| 6 | 1.1.4 | Discuss Implementation Budget and Schedule | 3d | 2006-09-08 | 2006-09-12 | 5 | 0d | start no earlier than 2006-03-27 | CMGT Project Team | 24h | 288 |
| 7 | 1.1.5 | Develop a benefits Implementatoin Project Charter | 3d | 2006-09-13 | 2006-09-15 | 6 | 0d | start no earlier than 2006-03-30 | CMGT Project Team | 24h | 288 |
| 8 | 1.1.6 | Approval from the Project Sponsors (HR, Senior Management) on Project Go Ahead | 3d | 2006-09-18 | 2006-09-20 | 7 | 0d | start no earlier than 2006-04-04 | Project Manager | 24h | 1,800 |
| 9 | 1.1.7 | Deliverable for Define Problem is the Feasibility Report | 3d | 2006-09-21 | 2006-09-25 | 8 | 0d |  | Project Manager | 24h | 1,800 |
| 10 | 1.2 | **Analyze Situation** | 25d? | 2006-09-26 | 2006-10-30 | 8 | 0d |  |  | 200h | 4,920 |
| 11 | 1.2.1 | Discuss the current and desired benefits desired with Huffman Trucking Employees | 3d | 2006-09-26 | 2006-09-28 | 9 | 0d |  | CMGT Project Team | 24h | 288 |
| 12 | 1.2.2 | Review the benefits that may be offered with HR Department | 11d | 2006-09-29 | 2006-10-13 | 11 | 0d |  | CMGT Project Team | 88h | 1,056 |
| 13 | 1.2.3 | Understand and document all Union and Non-Union Contracts | 1d | 2006-10-16 | 2006-10-16 | 12 | 0d |  | CMGT Project Team | 8h | 96 |
| 14 | 1.2.4 | Prepare Requirement Specification for multiple (type A and type B) Employee benefit Packages | 2d | 2006-10-17 | 2006-10-18 | 13 | 0d |  | CMGT Project Team | 16h | 192 |
| 15 | 1.2.5 | Approval of detailed Benefit Requirement Specification document from HR | 2d | 2006-10-19 | 2006-10-20 | 14 | 0d |  | Project Manager | 16h | 1,200 |
| 16 | 1.2.6 | Prepare a voting system for employees to bid on the different benefits packages | 1d? | 2006-10-23 | 2006-10-23 | 15 | 0d |  | CMGT Project Team | 8h | 96 |
| 17 | 1.2.7 | Collect data from employees on the preferred benefits plan | 1d? | 2006-10-24 | 2006-10-24 | 16 | 0d |  | CMGT Project Team | 8h | 96 |
| 18 | 1.2.8 | Share results with HR and finalize the benefits plan | 1d? | 2006-10-25 | 2006-10-25 | 17 | 0d |  | CMGT Project Team | 8h | 96 |
| 19 | 1.2.9 | Deliverable for Analyze Situation is the Requirements Document for multiple Benefits Package | 3d | 2006-10-26 | 2006-10-30 | 18 | 0d |  | Project Manager | 24h | 1,800 |
| 20 | 1.3 | **Design Solution** | 19d | 2006-10-31 | 2006-11-24 | 11 | 0d |  |  | 152h | 8,880 |
| 21 | 1.3.1 | Review Employee Benefit Requirement Specification Document | 3d | 2006-10-31 | 2006-11-02 | 19 | 0d |  | Designer | 24h | 960 |
| 22 | 1.3.2 | Map Benefits Requirements into System Requirements | 5d | 2006-11-03 | 2006-11-09 | 21 | 0d |  | Project Manager | 40h | 3,000 |
| 23 | 1.3.3 | Prepare High level design for benefit tracking of employees | 3d | 2006-11-10 | 2006-11-14 | 22 | 0d |  | Designer | 24h | 960 |
| 24 | 1.3.4 | Prepare Low level design for benefit tracking of employees | 3d | 2006-11-15 | 2006-11-17 | 23 | 0d |  | Designer | 24h | 960 |
| 25 | 1.3.5 | Approval of both high and Low level benefit design system | 2d | 2006-11-20 | 2006-11-21 | 24 | 0d |  | Project Manager | 16h | 1,200 |
| 26 | 1.3.6 | Deliverable for Design Solution is the Final Benefits Plan | 3d | 2006-11-22 | 2006-11-24 | 25 | 0d |  | Project Manager | 24h | 1,800 |

| ID | WBS | Task | Duration | Start | Finish | Predecessors | Total slack | Resources | Work | Cost |
| --- | --- | --- | --- | --- | --- | --- | --- | --- | --- | --- |
| 27 | 1.4 | **Implement Design** | 39d | 2006-11-27 | 2007-01-18 | 25 | 0d |  | 312h | 11,160 |
| 28 | 1.4.1 | Develop the benefits tracking solution | 20d | 2006-11-27 | 2006-12-22 | 26 | 0d | Developer | 160h | 4,800 |
| 29 | 1.4.2 | Unit Testing of different modules of Benefits Tracking | 3d | 2006-12-25 | 2006-12-27 | 28 | 0d | Developer | 24h | 720 |
| 30 | 1.4.3 | Module Testing of different Benefit tracking Modules | 4d | 2006-12-28 | 2007-01-02 | 29 | 0d | Developer | 32h | 960 |
| 31 | 1.4.4 | Integrating Testing of the New Benefits Tracking System | 7d | 2007-01-03 | 2007-01-11 | 30 | 0d | Tester | 56h | 1,680 |
| 32 | 1.4.5 | Approval of benefit tracking and availability standard of the Solution Developed | 2d | 2007-01-12 | 2007-01-15 | 31 | 0d | Project Manager | 16h | 1,200 |
| 33 | 1.4.6 | Deliverable for Implement Design is the Tested Product | 3d | 2007-01-16 | 2007-01-18 | 32 | 0d | Project Manager | 24h | 1,800 |
| 34 | 1.5 | **Support Product** | 243d? | 2006-03-13 | 2007-02-14 |  | 0d |  | 152h | 7,960 |
| 35 | 1.5.1 | Develop Employee Benefits Tracking system Training Manual | 7d | 2007-01-19 | 2007-01-29 | 33 | 0d | Business Analyst | 56h | 2,800 |
| 36 | 1.5.2 | Develop benefits Training Plan for HR and Employees | 2d | 2007-01-30 | 2007-01-31 | 35 | 0d | Business Analyst | 16h | 800 |
| 37 | 1.5.3 | Train Huffman Trucking Employees on the usage of Benefits claims through new system | 3d | 2007-02-01 | 2007-02-05 | 36 | 0d | Trainer | 24h | 720 |
| 38 | 1.5.4 | Train HR on the administration of benefits claims through new system | 1d | 2007-02-06 | 2007-02-06 | 37 | 0d | Trainer | 8h | 240 |
| 39 | 1.5.5 | Develop a maintenance/support plan for New Benefits Tracking System | 1d | 2007-02-07 | 2007-02-07 | 38 | 0d | Business Analyst | 8h | 400 |
| 40 | 1.5.6 | Approval of benefit Solution and maintenance plan | 2d | 2007-02-08 | 2007-02-09 | 39 | 0d | Project Manager | 16h | 1,200 |
| 41 | 1.5.7 | Deliverable for Support Product is the actual maintenance plan | 3d | 2007-02-12 | 2007-02-14 | 40 | 0d | Project Manager | 24h | 1,800 |
